# D3XX Android

Schedule from ProjectLibre, 2017-01-03 to 2017-03-03.

## Calendars

- Standard: Mon-Fri 08:00-12:00, 13:00-17:00; Sat-Sun off.

## Resources

| Resource |
| --- |
| Unassigned |
| Richmond |
| Arun |
| Samuel |
| Sree |

## Schedule

| ID | WBS | Task | Duration | Start | Finish | Total slack | Constraint | Resources |
| --- | --- | --- | --- | --- | --- | --- | --- | --- |
| 1 | 1 | **Research and Study** | 7d? | 2017-01-03 | 2017-01-11 | 3600d |  | Richmond |
| 2 | 1.1 | Android environment setup | 1d? | 2017-01-03 | 2017-01-03 |  | start no later than 2017-01-03 |  |
| 3 | 1.2 | Android UI development | 2d? | 2017-01-04 | 2017-01-05 |  | start no later than 2017-01-04 |  |
| 4 | 1.3 | Proof of Concept | 1d? | 2017-01-06 | 2017-01-06 |  | start no later than 2017-01-06 |  |
| 5 | 1.4 | Android USB development | 2d? | 2017-01-09 | 2017-01-10 |  | start no later than 2017-01-09 |  |
| 6 | 1.5 | D2XX Documents | 1d? | 2017-01-11 | 2017-01-11 |  | start no earlier than 2017-01-11 |  |
| 7 | 1.6 | Proof of Concept | 1d? | 2017-01-11 | 2017-01-11 |  | start no earlier than 2017-01-11 |  |
| 8 | 1.7 | Project Schedule Draft | 1d? | 2017-01-11 | 2017-01-11 | 3600d |  |  |
| 9 | 2 | **Prototyping and Requirements** | 7d? | 2017-01-12 | 2017-01-20 |  |  | Richmond |
| 10 | 2.1 | Library | 2d? | 2017-01-12 | 2017-01-13 |  | start no earlier than 2017-01-12 |  |
| 11 | 2.2 | Demo app | 2d? | 2017-01-16 | 2017-01-17 |  | start no earlier than 2017-01-16 |  |
| 12 | 2.3 | Performance investigation | 3d? | 2017-01-18 | 2017-01-20 |  | start no earlier than 2017-01-18 |  |
| 13 | 2.4 | Requirements Specification | 1d? | 2017-01-20 | 2017-01-20 |  | start no earlier than 2017-01-20 |  |
| 14 | 3 | **Design** | 1d? | 2017-02-06 | 2017-02-06 |  | start no earlier than 2017-01-18 | Richmond |
| 15 | 3.1 | Documentation | 1d? | 2017-02-06 | 2017-02-06 |  | start no earlier than 2017-02-06 |  |
| 16 | 4 | **Development** | 9d? | 2017-01-23 | 2017-02-02 |  | start no earlier than 2017-01-19 | Richmond |
| 17 | 4.1 | Cleanup: Data Streaming | 2d? | 2017-01-23 | 2017-01-24 | 600d | start no earlier than 2017-01-23 |  |
| 18 | 4.2 | Multiple Devices, Hotplugging | 1d? | 2017-01-25 | 2017-01-25 | 500d | start no earlier than 2017-01-25 |  |
| 19 | 4.3 | Cleanup: Data Loopback | 1d? | 2017-01-26 | 2017-01-26 | 400d | start no earlier than 2017-01-26 |  |
| 20 | 4.4 | Install Android on a PC, Make it work | 1d? | 2017-01-27 | 2017-01-27 | 300d | start no earlier than 2017-01-27 |  |
| 21 | 4.5 | DFU Implementation | 2d? | 2017-01-30 | 2017-01-31 | 100d | start no earlier than 2017-01-30 |  |
| 22 | 4.6 | JAR library, APK creation | 1d? | 2017-02-01 | 2017-02-01 |  | start no earlier than 2017-02-01 |  |
| 23 | 4.7 | UI Improvement | 1d? | 2017-02-02 | 2017-02-02 |  | start no earlier than 2017-02-02 |  |
| 24 | 5 | **Releases** | 20d? | 2017-02-03 | 2017-03-03 |  | start no earlier than 2017-02-03 |  |
| 25 | 5.1 | Alpha Release | 0d? | 2017-02-03 | 2017-02-03 | 2000d |  | Richmond |
| 26 | 5.2 | JavaDoc Documentation | 1d? | 2017-02-06 | 2017-02-06 | 1800d | start no earlier than 2017-02-06 |  |
| 27 | 5.3 | Data Correctness Validation | 2d? | 2017-02-07 | 2017-02-08 | 1600d | start no earlier than 2017-02-07 | Richmond |
| 28 | 5.4 | Performance Improvement | 5d? | 2017-02-10 | 2017-02-16 | 1000d | start no earlier than 2017-02-10 | Richmond |
| 29 | 5.5 | Review Process | 10d? | 2017-02-03 | 2017-02-16 | 1000d | start no earlier than 2017-02-03 | Arun |
| 30 | 5.6 | Beta Release | 0d? | 2017-02-17 | 2017-02-17 | 1000d | start no earlier than 2017-02-17 | Richmond |
| 31 | 5.7 | UI Improvement | 10d? | 2017-02-17 | 2017-03-02 |  | start no earlier than 2017-02-17 | Richmond |
| 32 | 5.8 | Testing and Review Process | 10d? | 2017-02-17 | 2017-03-02 |  | start no earlier than 2017-02-17 | Arun |
| 33 | 5.9 | Final Release | 0d? | 2017-03-03 | 2017-03-03 |  | start no earlier than 2017-03-03 | Richmond |
| 34 | 5.10 | Google Play Release | 0d? | 2017-03-03 | 2017-03-03 |  | start no earlier than 2017-03-03 | Richmond |
| 35 | 6 | JNI Investigation (if necessary) | 1d? | 2017-02-03 | 2017-02-03 |  | start no earlier than 2017-02-03 |  |
